# ssi-project2013-example_09

Schedule from MS Project, 2013-04-02 to 2013-06-12.
House build

## Calendars

- Building Calendar: Mon-Fri 09:00-13:00, 14:00-18:00; Sat-Sun off. Exceptions (off unless hours are given): 2013-01-01 to 2020-01-01 (New Years Day, recurring), 2013-05-06 (Early May Bank Holiday), 2013-05-27 (Spring Bank Holiday).

## Resources

| Resource | Unit |
| --- | --- |
| Bricklayer |  |
| Bricks | 000s |
| Carpenter |  |
| Door | Single |
| Window | Single |

## Schedule

| ID | WBS | Task | Duration | Start | Finish | Predecessors | Total slack | Constraint | Resources | Work |
| --- | --- | --- | --- | --- | --- | --- | --- | --- | --- | --- |
| 1 | 1 | **Prepare site** | 10d | 2013-04-02 | 2013-04-15 |  | 0d |  |  |  |
| 2 | 1.1 | Demolition | 5d | 2013-04-02 | 2013-04-08 |  | 0d | start no earlier than 2013-04-02 |  |  |
| 3 | 1.2 | Set out site | 1d | 2013-04-09 | 2013-04-09 | 2 | 0d | start no earlier than 2013-04-02 |  |  |
| 4 | 1.3 | Inground plumbing | 2d | 2013-04-10 | 2013-04-11 | 3 | 0d | start no earlier than 2013-04-02 |  |  |
| 5 | 1.4 | Excavation | 2d | 2013-04-12 | 2013-04-15 | 4 | 0d | start no earlier than 2013-04-02 |  |  |
| 6 | 2 | Lay foundation | 15d | 2013-04-16 | 2013-05-07 | 1 | 0d | start no earlier than 2013-03-18 |  |  |
| 7 | 3 | Build walls | 10d | 2013-05-08 | 2013-05-21 | 6 | 0d | start no earlier than 2013-03-25 | Bricklayer; Bricks [12 000s] | 80h |
| 8 | 4 | **Fit windows and doors** | 4d | 2013-05-22 | 2013-05-28 | 7 | 11d |  | Carpenter; Door [9 Single]; Window [12 Single] | 32h |
| 9 | 4.1 | **Fit doors** | 4d | 2013-05-22 | 2013-05-28 |  | 11d |  |  |  |
| 10 | 4.1.1 | Ground floor doors | 4d | 2013-05-22 | 2013-05-28 |  | 11d | start no earlier than 2013-04-02 |  |  |
| 11 | 4.1.2 | Upper floor doors | 2d | 2013-05-22 | 2013-05-23 |  | 13d | start no earlier than 2013-04-02 |  |  |
| 12 | 4.2 | **Fit windows** | 3d | 2013-05-22 | 2013-05-24 |  | 12d |  |  |  |
| 13 | 4.2.1 | Ground floor windows | 3d | 2013-05-22 | 2013-05-24 |  | 12d | start no earlier than 2013-04-02 |  |  |
| 14 | 4.2.2 | Upper floor windows | 3d | 2013-05-22 | 2013-05-24 |  | 12d | start no earlier than 2013-04-02 |  |  |
| 15 | 5 | Fit roof | 15d | 2013-05-22 | 2013-06-12 | 7 | 0d | start no earlier than 2013-03-25 |  |  |
