# ssi-project2013-example_11

Schedule from MS Project, 2013-04-02 to 2013-06-18.
House build

## Calendars

- Building Calendar: Mon-Fri 09:00-13:00, 14:00-18:00; Sat-Sun off. Exceptions (off unless hours are given): 2013-01-01 to 2020-01-01 (New Years Day, recurring), 2013-05-06 (Early May Bank Holiday), 2013-05-27 (Spring Bank Holiday).

## Resources

| Resource | Group | Unit |
| --- | --- | --- |
| Bricklayer | Brickie |  |
| Bricks |  | 000s |
| Carpenter | Carpenter |  |
| Door |  | Single |
| Window |  | Single |
| Jim Stansfield | Brickie |  |
| Jade Patterson | Carpenter |  |
| Ground Pump |  |  |
| Ground Pump fuel |  | litre |

## Schedule

| ID | WBS | Task | Type | Duration | Start | Finish | Predecessors | Total slack | Free slack | Constraint | Resources | Work |
| --- | --- | --- | --- | --- | --- | --- | --- | --- | --- | --- | --- | --- |
| 1 | 1 | **Prepare site** |  | 10d | 2013-04-02 09:00 | 2013-04-15 18:00 |  | 8.25d | 0d |  |  | 16h |
| 2 | 1.1 | Demolition |  | 5d | 2013-04-02 09:00 | 2013-04-08 18:00 |  | 8.25d | 0d | start no earlier than 2013-04-02 08:00 |  |  |
| 3 | 1.2 | Set out site |  | 1d | 2013-04-09 09:00 | 2013-04-09 18:00 | 2 | 8.25d | 0d | start no earlier than 2013-04-02 08:00 |  |  |
| 4 | 1.3 | Inground plumbing |  | 2d | 2013-04-10 09:00 | 2013-04-11 18:00 | 3 | 8.25d | 0d | start no earlier than 2013-04-02 08:00 |  |  |
| 5 | 1.4 | Excavation |  | 2d | 2013-04-12 09:00 | 2013-04-15 18:00 | 4 | 8.25d |  | start no earlier than 2013-04-02 08:00 | Ground Pump; Ground Pump fuel [1 litre] | 16h |
| 6 | 2 | Site prepared | milestone | 0d | 2013-04-15 18:00 | 2013-04-15 18:00 | 1 | 43.25d |  | start no earlier than 2013-04-03 08:00 |  |  |
| 7 | 3 | **Site Inspection** |  | 53.25d | 2013-04-02 09:00 | 2013-06-18 11:00 |  | 0d |  |  |  |  |
| 8 | 3.1 | Site Inspection 1 |  | 2h | 2013-04-02 09:00 | 2013-04-02 11:00 |  | 53d |  | start no earlier than 2013-04-02 09:00 |  |  |
| 9 | 3.2 | Site Inspection 2 |  | 2h | 2013-04-09 09:00 | 2013-04-09 11:00 |  | 48d |  | start no earlier than 2013-04-09 09:00 |  |  |
| 10 | 3.3 | Site Inspection 3 |  | 2h | 2013-04-16 09:00 | 2013-04-16 11:00 |  | 43d |  | start no earlier than 2013-04-16 09:00 |  |  |
| 11 | 3.4 | Site Inspection 4 |  | 2h | 2013-04-23 09:00 | 2013-04-23 11:00 |  | 38d |  | start no earlier than 2013-04-23 09:00 |  |  |
| 12 | 3.5 | Site Inspection 5 |  | 2h | 2013-04-30 09:00 | 2013-04-30 11:00 |  | 33d |  | start no earlier than 2013-04-30 09:00 |  |  |
| 13 | 3.6 | Site Inspection 6 |  | 2h | 2013-05-07 09:00 | 2013-05-07 11:00 |  | 29d |  | start no earlier than 2013-05-07 09:00 |  |  |
| 14 | 3.7 | Site Inspection 7 |  | 2h | 2013-05-14 09:00 | 2013-05-14 11:00 |  | 24d |  | start no earlier than 2013-05-14 09:00 |  |  |
| 15 | 3.8 | Site Inspection 8 |  | 2h | 2013-05-21 09:00 | 2013-05-21 11:00 |  | 19d |  | start no earlier than 2013-05-21 09:00 |  |  |
| 16 | 3.9 | Site Inspection 9 |  | 2h | 2013-05-28 09:00 | 2013-05-28 11:00 |  | 15d |  | start no earlier than 2013-05-28 09:00 |  |  |
| 17 | 3.10 | Site Inspection 10 |  | 2h | 2013-06-04 09:00 | 2013-06-04 11:00 |  | 10d |  | start no earlier than 2013-06-04 09:00 |  |  |
| 18 | 3.11 | Site Inspection 11 |  | 2h | 2013-06-11 09:00 | 2013-06-11 11:00 |  | 5d |  | start no earlier than 2013-06-11 09:00 |  |  |
| 19 | 3.12 | Site Inspection 12 |  | 2h | 2013-06-18 09:00 | 2013-06-18 11:00 |  | 0d |  | start no earlier than 2013-06-18 09:00 |  |  |
| 20 | 4 | **Lay foundation** |  | 11d | 2013-04-16 09:00 | 2013-04-30 18:00 | 1 | 8.25d | 0d |  |  |  |
| 21 | 4.1 | Footings and slabs | milestone | 3d | 2013-04-16 09:00 | 2013-04-18 18:00 |  | 8.25d | 0d | start no earlier than 2013-04-03 08:00 |  |  |
| 22 | 4.2 | Base brickwork |  | 2d | 2013-04-19 09:00 | 2013-04-22 18:00 | 21 | 8.25d | 0d | start no earlier than 2013-04-03 08:00 |  |  |
| 23 | 4.3 | Sub floor |  | 4d | 2013-04-23 09:00 | 2013-04-26 18:00 | 22 | 8.25d | 0d | start no earlier than 2013-04-03 08:00 |  |  |
| 24 | 4.4 | Suspended plumbing |  | 2d | 2013-04-29 09:00 | 2013-04-30 18:00 | 23 | 8.25d |  | start no earlier than 2013-04-03 08:00 |  |  |

Notes:
- 2: Planning to contact Acme Demolition about this. Need to know: / ·Cost / ·Availability (short notice!) / ·Contact name

| ID | WBS | Task | Type | Duration | Start | Finish | Predecessors | Total slack | Free slack | Constraint | Resources | Work |
| --- | --- | --- | --- | --- | --- | --- | --- | --- | --- | --- | --- | --- |
| 25 | 5 | **Build walls** |  | 10d | 2013-05-01 09:00 | 2013-05-15 18:00 | 20 | 8.25d | 0d |  | Bricklayer; Bricks [12 000s] | 160h |
| 26 | 5.1 | Ground floor walls |  | 5d | 2013-05-01 09:00 | 2013-05-08 18:00 |  | 8.25d | 0d | start no earlier than 2013-04-03 08:00 | Jim Stansfield | 40h |
| 27 | 5.2 | Upper floor walls |  | 5d | 2013-05-09 09:00 | 2013-05-15 18:00 | 26 | 8.25d |  | start no earlier than 2013-04-03 08:00 | Jim Stansfield | 40h |
| 28 | 6 | **Fit windows and doors** |  | 7d | 2013-05-16 09:00 | 2013-05-24 18:00 | 25 | 15.25d |  |  |  | 96h |
| 29 | 6.1 | **Fit doors** |  | 7d | 2013-05-16 09:00 | 2013-05-24 18:00 |  | 15.25d |  |  |  | 48h |
| 30 | 6.1.1 | Ground floor doors |  | 4d | 2013-05-21 09:00 | 2013-05-24 18:00 |  | 15.25d |  | start no earlier than 2013-04-02 08:00 | Door [5 Single]; Jade Patterson | 32h |
| 31 | 6.1.2 | Upper floor doors |  | 2d | 2013-05-16 09:00 | 2013-05-17 18:00 |  | 20.25d |  | start no earlier than 2013-04-02 08:00 | Door [4 Single]; Jade Patterson | 16h |
| 32 | 6.2 | **Fit windows** |  | 3d | 2013-05-16 09:00 | 2013-05-20 18:00 |  | 19.25d |  |  |  | 48h |
| 33 | 6.2.1 | Ground floor windows |  | 3d | 2013-05-16 09:00 | 2013-05-20 18:00 |  | 19.25d |  | start no earlier than 2013-04-02 08:00 | Window [6 Single]; Jade Patterson | 24h |
| 34 | 6.2.2 | Upper floor windows |  | 3d | 2013-05-16 09:00 | 2013-05-20 18:00 |  | 19.25d |  | start no earlier than 2013-04-02 08:00 | Window [6 Single]; Jade Patterson | 24h |
| 35 | 7 | **Fit roof** |  | 14d | 2013-05-16 09:00 | 2013-06-05 18:00 | 25 | 8.25d | 0d |  |  |  |
| 36 | 7.1 | Trusses and frame |  | 5d | 2013-05-16 09:00 | 2013-05-22 18:00 |  | 8.25d | 0d | start no earlier than 2013-04-03 08:00 |  |  |
| 37 | 7.2 | Lining and tiles |  | 6d | 2013-05-23 09:00 | 2013-05-31 18:00 | 36 | 8.25d | 0d | start no earlier than 2013-04-03 08:00 |  |  |
| 38 | 7.3 | Finishing |  | 3d | 2013-06-03 09:00 | 2013-06-05 18:00 | 37 | 8.25d |  | start no earlier than 2013-04-03 08:00 |  |  |
| 39 | 8 | Building Complete | milestone | 0d | 2013-06-05 18:00 | 2013-06-05 18:00 | 35 | 8.25d |  | start no earlier than 2013-04-03 08:00 |  |  |
