# ssi-project2013-example_15

Schedule from MS Project, 2013-04-02 to 2013-06-18, status date 2013-04-05, costs in $, A marks actual dates.
House build

## Calendars

- Building Calendar: Mon-Fri 09:00-13:00, 14:00-18:00; Sat-Sun off. Exceptions (off unless hours are given): 2013-01-01 to 2020-01-01 (New Years Day, recurring), 2013-05-06 (Early May Bank Holiday), 2013-05-27 (Spring Bank Holiday).

## Resources

| Resource | Group | Unit | Rate | Cost per use |
| --- | --- | --- | --- | --- |
| Bricklayer | Brickie |  | 22 |  |
| Bricks |  | 000s | 450 | 100 |
| Carpenter | Carpenter |  | 22 |  |
| Door |  | Single | 250 |  |
| Window |  | Single | 300 |  |
| Jim Stansfield | Brickie |  | 22.5 |  |
| Jade Patterson | Carpenter |  | 22.5 |  |
| Ground Pump |  |  | 2.5 | 75 |
| Ground Pump fuel |  | litre | 0.6 |  |
| Laborer | Laborer |  | 20 |  |
| Roofer | Roofer |  | 24 |  |
| Toby Arnott |  |  | 30 |  |
| Site Foreman |  |  | 28 |  |
| Plumber |  |  | 25 |  |
| Incidental expenses |  |  |  |  |
| Glazing Inspector |  |  |  | 299 |

## Schedule

| ID | WBS | Task | Type | Duration | Start | Finish | Predecessors | Complete | Remaining | Baseline start | Baseline finish | Baseline duration | Total slack | Constraint | Resources | Work | Actual work | Cost | Baseline cost | Actual cost |
| --- | --- | --- | --- | --- | --- | --- | --- | --- | --- | --- | --- | --- | --- | --- | --- | --- | --- | --- | --- | --- |
| 1 | 1 | **Site Inspection** |  | 53.25d | 2013-04-02 09:00 A | 2013-06-18 11:00 |  | 8% | 48.81d | 2013-04-02 09:00 | 2013-06-18 11:00 | 53.25d | 0d |  |  | 48h | 4h | 1,392 | 1,392 | 116 |
| 2 | 1.1 | Site Inspection 1 |  | 2h | 2013-04-02 09:00 A | 2013-04-02 11:00 A |  | 100% |  | 2013-04-02 09:00 | 2013-04-02 11:00 | 2h |  | start no earlier than 2013-04-02 09:00 | Site Foreman; Toby Arnott | 4h | 4h | 116 | 116 | 116 |
| 3 | 1.2 | Site Inspection 2 |  | 2h | 2013-04-09 09:00 | 2013-04-09 11:00 |  |  |  | 2013-04-09 09:00 | 2013-04-09 11:00 | 2h | 48d | start no earlier than 2013-04-09 09:00 | Site Foreman; Toby Arnott | 4h |  | 116 | 116 |  |
| 4 | 1.3 | Site Inspection 3 |  | 2h | 2013-04-16 09:00 | 2013-04-16 11:00 |  |  |  | 2013-04-16 09:00 | 2013-04-16 11:00 | 2h | 43d | start no earlier than 2013-04-16 09:00 | Site Foreman; Toby Arnott | 4h |  | 116 | 116 |  |
| 5 | 1.4 | Site Inspection 4 |  | 2h | 2013-04-23 09:00 | 2013-04-23 11:00 |  |  |  | 2013-04-23 09:00 | 2013-04-23 11:00 | 2h | 38d | start no earlier than 2013-04-23 09:00 | Site Foreman; Toby Arnott | 4h |  | 116 | 116 |  |
| 6 | 1.5 | Site Inspection 5 |  | 2h | 2013-04-30 09:00 | 2013-04-30 11:00 |  |  |  | 2013-04-30 09:00 | 2013-04-30 11:00 | 2h | 33d | start no earlier than 2013-04-30 09:00 | Site Foreman; Toby Arnott | 4h |  | 116 | 116 |  |
| 7 | 1.6 | Site Inspection 6 |  | 2h | 2013-05-07 09:00 | 2013-05-07 11:00 |  |  |  | 2013-05-07 09:00 | 2013-05-07 11:00 | 2h | 29d | start no earlier than 2013-05-07 09:00 | Site Foreman; Toby Arnott | 4h |  | 116 | 116 |  |
| 8 | 1.7 | Site Inspection 7 |  | 2h | 2013-05-14 09:00 | 2013-05-14 11:00 |  |  |  | 2013-05-14 09:00 | 2013-05-14 11:00 | 2h | 24d | start no earlier than 2013-05-14 09:00 | Site Foreman; Toby Arnott | 4h |  | 116 | 116 |  |
| 9 | 1.8 | Site Inspection 8 |  | 2h | 2013-05-21 09:00 | 2013-05-21 11:00 |  |  |  | 2013-05-21 09:00 | 2013-05-21 11:00 | 2h | 19d | start no earlier than 2013-05-21 09:00 | Site Foreman; Toby Arnott | 4h |  | 116 | 116 |  |
| 10 | 1.9 | Site Inspection 9 |  | 2h | 2013-05-28 09:00 | 2013-05-28 11:00 |  |  |  | 2013-05-28 09:00 | 2013-05-28 11:00 | 2h | 15d | start no earlier than 2013-05-28 09:00 | Site Foreman; Toby Arnott | 4h |  | 116 | 116 |  |
| 11 | 1.10 | Site Inspection 10 |  | 2h | 2013-06-04 09:00 | 2013-06-04 11:00 |  |  |  | 2013-06-04 09:00 | 2013-06-04 11:00 | 2h | 10d | start no earlier than 2013-06-04 09:00 | Site Foreman; Toby Arnott | 4h |  | 116 | 116 |  |
| 12 | 1.11 | Site Inspection 11 |  | 2h | 2013-06-11 09:00 | 2013-06-11 11:00 |  |  |  | 2013-06-11 09:00 | 2013-06-11 11:00 | 2h | 5d | start no earlier than 2013-06-11 09:00 | Site Foreman; Toby Arnott | 4h |  | 116 | 116 |  |
| 13 | 1.12 | Site Inspection 12 |  | 2h | 2013-06-18 09:00 | 2013-06-18 11:00 |  |  |  | 2013-06-18 09:00 | 2013-06-18 11:00 | 2h | 0d | start no earlier than 2013-06-18 09:00 | Site Foreman; Toby Arnott | 4h |  | 116 | 116 |  |
| 14 | 2 | **Prepare site** |  | 10d | 2013-04-02 09:00 A | 2013-04-15 18:00 |  | 40% | 6d | 2013-04-02 09:00 | 2013-04-15 18:00 | 10d | 0d |  |  | 96h | 32h | 1,914.6 | 1,914.6 | 640 |
| 15 | 2.1 | Demolition |  | 5d | 2013-04-02 09:00 A | 2013-04-08 18:00 |  | 80% | 1d | 2013-04-02 09:00 | 2013-04-08 18:00 | 5d | 0d |  | Laborer | 40h | 32h | 800 | 800 | 640 |
| 16 | 2.2 | Set out site |  | 1d | 2013-04-09 09:00 | 2013-04-09 18:00 | 15 |  |  | 2013-04-09 09:00 | 2013-04-09 18:00 | 1d | 0d |  | Laborer | 8h |  | 160 | 160 |  |
| 17 | 2.3 | Inground plumbing |  | 2d | 2013-04-10 09:00 | 2013-04-11 18:00 | 16 |  |  | 2013-04-10 09:00 | 2013-04-11 18:00 | 2d | 0d |  | Laborer | 16h |  | 510 | 510 |  |
| 18 | 2.4 | Excavation |  | 2d | 2013-04-12 09:00 | 2013-04-15 18:00 | 17 |  |  | 2013-04-12 09:00 | 2013-04-15 18:00 | 2d | 0d |  | Ground Pump; Ground Pump fuel [1 litre]; Laborer | 32h |  | 444.6 | 444.6 |  |
| 19 | 3 | Site prepared | milestone | 0d | 2013-04-15 18:00 | 2013-04-15 18:00 | 14 |  |  | 2013-04-15 18:00 | 2013-04-15 18:00 |  | 43.25d | start no earlier than 2013-04-03 08:00 |  |  |  |  |  |  |
| 20 | 4 | **Lay foundation** |  | 9d | 2013-04-16 09:00 | 2013-04-26 18:00 | 14 |  |  | 2013-04-16 09:00 | 2013-04-26 18:00 | 9d | 0d |  |  | 88h |  | 1,872 | 1,872 |  |
| 21 | 4.1 | Footings and slabs | milestone | 3d | 2013-04-16 09:00 | 2013-04-18 18:00 |  |  |  | 2013-04-16 09:00 | 2013-04-18 18:00 | 3d | 0d |  | Laborer | 24h |  | 480 | 480 |  |
| 22 | 4.2 | Base brickwork |  | 2d | 2013-04-19 09:00 | 2013-04-22 18:00 | 21 |  |  | 2013-04-19 09:00 | 2013-04-22 18:00 | 2d | 0d |  | Bricklayer | 16h |  | 352 | 352 |  |
| 23 | 4.3 | Sub floor |  | 4d | 2013-04-23 09:00 | 2013-04-26 18:00 | 22 |  |  | 2013-04-23 09:00 | 2013-04-26 18:00 | 4d | 0d |  | Laborer | 32h |  | 640 | 640 |  |
| 24 | 4.4 | Suspended plumbing |  | 2d | 2013-04-25 09:00 | 2013-04-26 18:00 | 23SS+2d |  |  | 2013-04-25 09:00 | 2013-04-26 18:00 | 2d | 0d |  | Plumber | 16h |  | 400 | 400 |  |

Notes:
- 15: Planning to contact Acme Demolition about this. Need to know: / ·Cost / ·Availability (short notice!) / ·Contact name

| ID | WBS | Task | Type | Duration | Start | Finish | Predecessors | Baseline start | Baseline finish | Baseline duration | Total slack | Constraint | Deadline | Resources | Work | Cost | Baseline cost |
| --- | --- | --- | --- | --- | --- | --- | --- | --- | --- | --- | --- | --- | --- | --- | --- | --- | --- |
| 25 | 5 | **Build walls** |  | 10d | 2013-04-29 09:00 | 2013-05-13 18:00 | 20 | 2013-04-29 09:00 | 2013-05-13 18:00 | 10d | 0d |  |  |  | 80h | 7,400 | 7,400 |
| 26 | 5.1 | Ground floor walls |  | 5d | 2013-04-29 09:00 | 2013-05-03 18:00 |  | 2013-04-29 09:00 | 2013-05-03 18:00 | 5d | 0d |  |  | Jim Stansfield; Bricks [6 000s] | 40h | 3,700 | 3,700 |
| 27 | 5.2 | Upper floor walls |  | 5d | 2013-05-07 09:00 | 2013-05-13 18:00 | 26 | 2013-05-07 09:00 | 2013-05-13 18:00 | 5d | 0d |  |  | Jim Stansfield; Bricks [6 000s] | 40h | 3,700 | 3,700 |
| 28 | 6 | **Fit windows and doors** |  | 12d | 2013-05-07 09:00 | 2013-05-22 18:00 |  | 2013-05-07 09:00 | 2013-05-22 18:00 | 12d | 17.25d |  |  | Glazing Inspector | 192h | 8,309 | 8,309 |
| 29 | 6.1 | **Fit doors** |  | 9d | 2013-05-10 09:00 | 2013-05-22 18:00 |  | 2013-05-10 09:00 | 2013-05-22 18:00 | 9d | 17.25d |  |  |  | 48h | 3,330 | 3,330 |
| 30 | 6.1.1 | Ground floor doors |  | 4d | 2013-05-10 09:00 | 2013-05-20 18:00 | 26 | 2013-05-10 09:00 | 2013-05-20 18:00 | 4d | 19.25d |  |  | Door [5 Single]; Jade Patterson | 32h | 1,970 | 1,970 |
| 31 | 6.1.2 | Upper floor doors |  | 2d | 2013-05-21 09:00 | 2013-05-22 18:00 | 27 | 2013-05-21 09:00 | 2013-05-22 18:00 | 2d | 17.25d |  |  | Door [4 Single]; Jade Patterson | 16h | 1,360 | 1,360 |
| 32 | 6.2 | **Fit windows** |  | 8d | 2013-05-07 09:00 | 2013-05-16 18:00 |  | 2013-05-07 09:00 | 2013-05-16 18:00 | 8d | 21.25d |  |  |  | 48h | 4,680 | 4,680 |
| 33 | 6.2.1 | Ground floor windows |  | 3d | 2013-05-07 09:00 | 2013-05-09 18:00 | 26 | 2013-05-07 09:00 | 2013-05-09 18:00 | 3d | 26.25d |  |  | Window [6 Single]; Jade Patterson | 24h | 2,340 | 2,340 |
| 34 | 6.2.2 | Upper floor windows |  | 3d | 2013-05-14 09:00 | 2013-05-16 18:00 | 27 | 2013-05-14 09:00 | 2013-05-16 18:00 | 3d | 21.25d |  |  | Window [6 Single]; Jade Patterson | 24h | 2,340 | 2,340 |
| 35 | 7 | **Fit roof** |  | 13d | 2013-05-14 09:00 | 2013-05-31 18:00 | 25 | 2013-05-14 09:00 | 2013-05-31 18:00 | 13d | 0d |  |  |  | 112h | 2,776 | 2,776 |
| 36 | 7.1 | Trusses and frame |  | 5d | 2013-05-14 09:00 | 2013-05-20 18:00 |  | 2013-05-14 09:00 | 2013-05-20 18:00 | 5d | 0d | start no earlier than 2013-05-13 09:00 |  | Roofer | 40h | 960 | 960 |
| 37 | 7.2 | Lining and tiles |  | 5d | 2013-05-21 09:00 | 2013-05-28 18:00 | 36 | 2013-05-21 09:00 | 2013-05-28 18:00 | 5d | 0d |  |  | Roofer | 48h | 1,240 | 1,240 |
| 38 | 7.3 | Finishing |  | 3d | 2013-05-29 09:00 | 2013-05-31 18:00 | 37FS-1d | 2013-05-29 09:00 | 2013-05-31 18:00 | 3d | 0d |  |  | Roofer | 24h | 576 | 576 |
| 39 | 8 | Building Complete | milestone | 0d | 2013-05-31 18:00 | 2013-05-31 18:00 | 35 | 2013-05-31 18:00 | 2013-05-31 18:00 |  | 0d |  | 2013-05-31 18:00 |  |  |  |  |

Notes:
- 36: Timber not avaialble until May 13. World shortage!
